# GANTT

Schedule from MS Project, 2018-02-28 to 2018-06-19, status date 2018-06-29, 7 hours a day, costs in €, A marks actual dates.

## Calendars

- Standard: Mon-Fri 09:00-12:00, 14:00-18:00; Sat-Sun off. Exceptions (off unless hours are given): 2018-03-26 to 2018-03-30 (Easter Holidays), 2018-05-07 to 2018-05-11 (Student Week).

## Resources

| Resource | Rate |
| --- | --- |
| Damien | 10 |
| Maarten | 10 |
| Maria | 10 |
| Moustafa | 10 |
| Wouter | 10 |
| Arduino |  |
| MQ-135 |  |
| BME 280 |  |
| OLED |  |
| PIR |  |
| Battery |  |
| Breadboard |  |
| Wire cables | 5.5 |
| Green LED | 1.6 |
| Red LED | 1.6 |
| White LED | 2.4 |
| Solar Pannel | 25.8 |
| Wood Batten | 7.98 |
| Screw | 8.99 |
| Galvanised support | 3.98 |
| Mesh Box | 10 |
| PVC Pannel | 12.99 |
| Wood Pannel | 5.98 |
| Resistors | 6.2 |

## Schedule

| ID | WBS | Task | Type | Duration | Start | Finish | Predecessors | Complete | Baseline start | Baseline finish | Baseline duration | Deadline | Resources | Work | Actual work | Cost | Actual cost |
| --- | --- | --- | --- | --- | --- | --- | --- | --- | --- | --- | --- | --- | --- | --- | --- | --- | --- |
| 1 | 1 | **Multipurpose Urban Equipment** |  | 70d | 2018-02-28 A | 2018-06-19 A |  | 100% | 2018-02-28 | 2018-06-19 | 70d |  |  | 1744.05h | 1744.05h | 17,440.5 | 17,440.5 |
| 2 | 1.1 | **HLD - High Level Definition** |  | 3.5d | 2018-02-28 A | 2018-03-05 A |  | 100% | 2018-02-28 | 2018-03-05 | 3.5d |  |  | 122.5h | 122.5h | 1,225 | 1,225 |
| 3 | 1.1.1 | **Research** |  | 1.5d | 2018-02-28 A | 2018-03-01 A |  | 100% | 2018-02-28 | 2018-03-01 | 1.5d |  |  | 52.5h | 52.5h | 525 | 525 |
| 4 | 1.1.1.1 | Market Research |  | 1d | 2018-02-28 A | 2018-02-28 A |  | 100% | 2018-02-28 | 2018-02-28 | 1d |  | Damien; Maarten; Maria; Moustafa; Wouter | 35h | 35h | 350 | 350 |
| 5 | 1.1.1.2 | Technical Research |  | 0.5d | 2018-03-01 A | 2018-03-01 A |  | 100% | 2018-03-01 | 2018-03-01 | 0.5d |  | Damien; Maarten; Maria; Moustafa; Wouter | 17.5h | 17.5h | 175 | 175 |
| 6 | 1.1.2 | **Planning** |  | 2d | 2018-03-01 A | 2018-03-05 A | 3 | 100% | 2018-03-01 | 2018-03-05 | 2d |  |  | 70h | 70h | 700 | 700 |
| 7 | 1.1.2.1 | Task Identification |  | 0.5d | 2018-03-01 A | 2018-03-01 A |  | 100% | 2018-03-01 | 2018-03-01 | 0.5d |  | Damien; Maarten; Maria; Moustafa; Wouter | 17.5h | 17.5h | 175 | 175 |
| 8 | 1.1.2.2 | Task Allocation |  | 0.5d | 2018-03-02 A | 2018-03-02 A | 7 | 100% | 2018-03-02 | 2018-03-02 | 0.5d |  | Damien; Maarten; Maria; Moustafa; Wouter | 17.5h | 17.5h | 175 | 175 |
| 9 | 1.1.2.3 | Gantt Chart |  | 1d | 2018-03-02 A | 2018-03-05 A | 8 | 100% | 2018-03-02 | 2018-03-05 | 1d |  | Damien; Maarten; Maria; Moustafa; Wouter | 35h | 35h | 350 | 350 |
| 10 | 1.1.2.4 | Deliver project plan | milestone | 0d | 2018-03-05 A | 2018-03-05 A | 7, 8, 9 | 100% | 2018-03-05 | 2018-03-05 | 0d | 2018-03-05 |  |  |  |  |  |
| 11 | 1.2 | **LLD - Low Level Definition** |  | 8d | 2018-03-05 A | 2018-03-15 A | 2 | 100% | 2018-03-05 | 2018-03-15 | 8d |  |  | 280h | 280h | 2,800 | 2,800 |
| 12 | 1.2.1 | **BlackBox** |  | 5d | 2018-03-05 A | 2018-03-12 A |  | 100% | 2018-03-05 | 2018-03-12 | 5d |  |  | 175h | 175h | 1,750 | 1,750 |
| 13 | 1.2.1.1 | BlackBox Diagrams |  | 2d | 2018-03-05 A | 2018-03-07 A |  | 100% | 2018-03-05 | 2018-03-07 | 2d |  | Damien; Maarten; Maria; Moustafa; Wouter | 70h | 70h | 700 | 700 |
| 14 | 1.2.1.2 | Structural Drafts |  | 3d | 2018-03-07 A | 2018-03-12 A | 13 | 100% | 2018-03-07 | 2018-03-12 | 3d |  | Damien; Maarten; Maria; Moustafa; Wouter | 105h | 105h | 1,050 | 1,050 |
| 15 | 1.2.1.3 | Deliver Blackbox | milestone | 0d | 2018-03-12 A | 2018-03-12 A | 13, 14 | 100% | 2018-03-12 | 2018-03-12 | 0d | 2018-03-12 |  |  |  |  |  |
| 16 | 1.2.2 | **Detailed Design** |  | 3d | 2018-03-12 A | 2018-03-15 A | 12 | 100% | 2018-03-12 | 2018-03-15 | 3d |  |  | 105h | 105h | 1,050 | 1,050 |
| 17 | 1.2.2.1 | Detailed Schematics |  | 3d | 2018-03-12 A | 2018-03-15 A |  | 100% | 2018-03-12 | 2018-03-15 | 3d |  | Damien [75%]; Maarten | 36.75h | 36.75h | 367.5 | 367.5 |
| 18 | 1.2.2.2 | Structural Drawings |  | 3d | 2018-03-12 A | 2018-03-15 A |  | 100% | 2018-03-12 | 2018-03-15 | 3d |  | Maria; Wouter [75%] | 36.75h | 36.75h | 367.5 | 367.5 |
| 19 | 1.2.2.3 | CardBoard Model |  | 3d | 2018-03-12 A | 2018-03-15 A |  | 100% | 2018-03-12 | 2018-03-15 | 3d |  | Damien [25%]; Moustafa; Wouter [25%] | 31.5h | 31.5h | 315 | 315 |
| 20 | 1.2.2.4 | Deliver Detailed Design | milestone | 0d | 2018-03-15 A | 2018-03-15 A | 12, 17, 18, 19 | 100% | 2018-03-15 | 2018-03-15 | 0d | 2018-03-23 |  |  |  |  |  |
| 21 | 1.3 | **Material & Budget** |  | 8.5d | 2018-03-15 A | 2018-04-03 A | 11 | 100% | 2018-03-15 | 2018-04-03 | 8.5d | 2018-04-04 |  | 220.5h | 220.5h | 2,205 | 2,205 |
| 22 | 1.3.1 | Selection Material & Components |  | 5d | 2018-03-15 A | 2018-03-22 A |  | 100% | 2018-03-15 | 2018-03-22 | 5d |  | Damien [90%]; Maarten [90%]; Maria [90%]; Moustafa [90%]; Wouter [90%] | 157.5h | 157.5h | 1,575 | 1,575 |
| 23 | 1.3.2 | Cost Calculations |  | 2d | 2018-04-02 A | 2018-04-03 A |  | 100% | 2018-04-02 | 2018-04-03 | 2d |  | Damien [90%]; Maarten [90%]; Maria [90%]; Moustafa [90%]; Wouter [90%] | 63h | 63h | 630 | 630 |
| 24 | 1.4 | **Interim** |  | 8d | 2018-04-04 A | 2018-04-16 A |  | 100% | 2018-04-04 | 2018-04-16 | 8d |  |  | 252h | 252h | 2,520 | 2,520 |
| 25 | 1.4.1 | Interim Report |  | 4d | 2018-04-04 A | 2018-04-10 A |  | 100% | 2018-04-04 | 2018-04-10 | 4d |  | Damien [90%]; Maarten [90%]; Maria [90%]; Moustafa [90%]; Wouter [90%] | 126h | 126h | 1,260 | 1,260 |
| 26 | 1.4.2 | Interim Presentation |  | 2d | 2018-04-10 A | 2018-04-12 A | 25 | 100% | 2018-04-10 | 2018-04-12 | 2d |  | Damien [90%]; Maarten [90%]; Maria [90%]; Moustafa [90%]; Wouter [90%] | 63h | 63h | 630 | 630 |
| 27 | 1.4.3 | Upload Interim Deliverables & Send S&P Assessment |  | 1d | 2018-04-12 A | 2018-04-13 A | 26 | 100% | 2018-04-12 | 2018-04-13 | 1d | 2018-04-13 | Damien [90%]; Maarten [90%]; Maria [90%]; Moustafa [90%]; Wouter [90%] | 31.5h | 31.5h | 315 | 315 |
| 28 | 1.4.4 | Interim Presentation Session |  | 1d | 2018-04-13 A | 2018-04-16 A | 27 | 100% | 2018-04-13 | 2018-04-16 | 1d | 2018-04-19 | Damien [90%]; Maarten [90%]; Maria [90%]; Moustafa [90%]; Wouter [90%] | 31.5h | 31.5h | 315 | 315 |
| 29 | 1.5 | Selection of Local Providers & Final List of Materials & Components |  | 1d | 2018-04-16 A | 2018-04-17 A | 24 | 100% | 2018-04-16 | 2018-04-17 | 1d | 2018-04-23 | Damien [90%]; Maarten [90%]; Maria [90%]; Moustafa [90%]; Wouter [90%] | 31.5h | 31.5h | 315 | 315 |

| ID | WBS | Task | Type | Duration | Start | Finish | Predecessors | Complete | Baseline start | Baseline finish | Baseline duration | Constraint | Deadline | Resources | Work | Actual work | Cost | Actual cost |
| --- | --- | --- | --- | --- | --- | --- | --- | --- | --- | --- | --- | --- | --- | --- | --- | --- | --- | --- |
| 30 | 1.6 | **Construction** |  | 21d | 2018-04-17 A | 2018-05-23 A | 29 | 100% | 2018-04-17 | 2018-05-23 | 21d |  | 2018-06-01 |  | 446.95h | 446.95h | 4,469.5 | 4,469.5 |
| 31 | 1.6.1 | **Hardware** |  | 21d | 2018-04-17 A | 2018-05-23 A |  | 100% | 2018-04-17 | 2018-05-23 | 21d |  |  |  | 269.5h | 269.5h | 2,695 | 2,695 |
| 32 | 1.6.1.1 | Sensors |  | 5d | 2018-04-17 A | 2018-04-24 A |  | 100% | 2018-04-17 | 2018-04-24 | 5d |  |  | Damien [25%]; Moustafa [25%] | 17.5h | 17.5h | 175 | 175 |
| 33 | 1.6.1.2 | Base |  | 10d | 2018-04-17 A | 2018-05-01 A |  | 100% | 2018-04-17 | 2018-05-01 | 10d |  |  | Maarten [45%]; Maria [45%]; Wouter [45%] | 94.5h | 94.5h | 945 | 945 |
| 34 | 1.6.1.3 | Case |  | 20d | 2018-04-18 A | 2018-05-23 A |  | 100% | 2018-04-18 | 2018-05-23 | 20d |  |  | Maarten [45%]; Wouter [45%]; Damien [45%] | 157.5h | 157.5h | 1,575 | 1,575 |
| 35 | 1.6.2 | **Software** |  | 20d | 2018-04-17 A | 2018-05-22 A |  | 100% | 2018-04-17 | 2018-05-22 | 20d |  |  |  | 177.45h | 177.45h | 1,774.5 | 1,774.5 |
| 36 | 1.6.2.1 | Arduino Code |  | 20d | 2018-04-17 A | 2018-05-22 A |  | 100% | 2018-04-17 | 2018-05-22 | 20d |  |  | Damien [65%]; Moustafa [65%] | 177.45h | 177.45h | 1,774.5 | 1,774.5 |
| 37 | 1.7 | Refined Report | milestone | 0d | 2018-02-28 A | 2018-02-28 A |  | 100% | 2018-02-28 | 2018-02-28 | 0d |  | 2018-05-02 | Damien; Maarten; Maria; Moustafa; Wouter |  |  |  |  |
| 38 | 1.8 | **Functional Tests & Results** |  | 4d | 2018-05-23 A | 2018-05-29 A | 30 | 100% | 2018-05-23 | 2018-05-29 | 4d |  | 2018-06-04 |  | 77h | 77h | 770 | 770 |
| 39 | 1.8.1 | Unit Testing |  | 2d | 2018-05-23 A | 2018-05-25 A |  | 100% | 2018-05-23 | 2018-05-25 | 2d |  |  | Damien [90%]; Moustafa [90%] | 25.2h | 25.2h | 252 | 252 |
| 40 | 1.8.2 | Product Testing |  | 2d | 2018-05-25 A | 2018-05-29 A | 39 | 100% | 2018-05-25 | 2018-05-29 | 2d |  |  | Damien [10%]; Maarten [90%]; Maria [90%]; Wouter [90%]; Moustafa [10%] | 40.6h | 40.6h | 406 | 406 |
| 41 | 1.8.3 | Corrections |  | 2d | 2018-05-25 A | 2018-05-29 A | 39 | 100% | 2018-05-25 | 2018-05-29 | 2d |  |  | Damien [80%]; Moustafa [80%] | 11.2h | 11.2h | 112 | 112 |
| 42 | 1.9 | **Upload final report** |  | 52d | 2018-04-02 A | 2018-06-19 A | 11 | 100% | 2018-04-02 | 2018-06-19 | 52d |  |  |  | 313.6h | 313.6h | 3,136 | 3,136 |
| 43 | 1.9.1 | Write Report |  | 49d | 2018-04-02 A | 2018-06-14 A |  | 100% | 2018-04-02 | 2018-06-14 | 49d | start no earlier than 2018-04-02 |  | Damien [10%]; Maarten [10%]; Maria [10%]; Moustafa [10%]; Wouter [10%] | 169.75h | 169.75h | 1,697.5 | 1,697.5 |
| 44 | 1.9.2 | Upload Report | milestone | 0d | 2018-06-15 A | 2018-06-15 A | 43 | 100% | 2018-06-15 | 2018-06-15 | 0d | must finish on 2018-06-15 |  | Damien; Maarten; Maria; Moustafa; Wouter |  |  |  |  |
| 45 | 1.9.3 | Paper |  | 7.5d | 2018-06-01 A | 2018-06-12 A | 41 | 100% | 2018-06-01 | 2018-06-12 | 7.5d |  |  | Damien [10%]; Maarten [10%]; Maria [10%]; Moustafa [70%]; Wouter [10%] | 57.75h | 57.75h | 577.5 | 577.5 |
| 46 | 1.9.4 | Leaflet |  | 5d | 2018-06-01 A | 2018-06-08 A | 41 | 100% | 2018-06-01 | 2018-06-08 | 5d |  |  | Maria [70%] | 24.5h | 24.5h | 245 | 245 |
| 47 | 1.9.5 | Video |  | 3d | 2018-06-08 A | 2018-06-13 A | 41 | 100% | 2018-06-08 | 2018-06-13 | 3d |  |  | Damien [10%]; Maarten [10%]; Maria [70%]; Moustafa [10%]; Wouter [10%] | 23.1h | 23.1h | 231 | 231 |
| 48 | 1.9.6 | Evaluation | manual | 0.5d | 2018-05-29 A | 2018-05-29 A | 41 | 100% | 2018-05-29 | 2018-05-30 | 1d |  |  | Damien [10%]; Maarten [10%]; Maria [10%]; Moustafa [10%]; Wouter [70%] | 3.85h | 3.85h | 38.5 | 38.5 |
| 49 | 1.9.7 | Presentation |  | 3d | 2018-06-15 A | 2018-06-19 A | 43 | 100% | 2018-06-15 | 2018-06-19 | 3d |  |  | Damien [10%]; Maarten [70%]; Maria [10%]; Moustafa [10%]; Wouter [10%] | 23.1h | 23.1h | 231 | 231 |
| 50 | 1.9.8 | Demonstration |  | 1d | 2018-05-29 A | 2018-05-30 A | 41 | 100% | 2018-05-29 | 2018-05-30 | 1d |  |  | Damien [10%]; Maarten [10%]; Maria [70%]; Moustafa [10%]; Wouter [10%] | 7.7h | 7.7h | 77 | 77 |
| 51 | 1.9.9 | Manual | manual | 0.5d | 2018-06-01 A | 2018-06-01 A | 41 | 100% | 2018-05-29 | 2018-06-01 | 3d | finish no earlier than 2018-06-15 |  | Damien [70%]; Maarten [10%]; Maria [10%]; Moustafa [10%]; Wouter [10%] | 3.85h | 3.85h | 38.5 | 38.5 |
| 52 | 1.9.10 | Upload Other | milestone | 0d | 2018-06-18 A | 2018-06-18 A | 45, 46, 47, 48, 49, 50, 51 | 100% | 2018-06-18 | 2018-06-18 | 0d | must finish on 2018-06-18 |  | Damien; Maarten; Maria; Moustafa; Wouter |  |  |  |  |
| 53 | 1.10 | Final Presentation & Assessment | milestone | 0d | 2018-02-28 A | 2018-02-28 A |  | 100% | 2018-02-28 | 2018-02-28 | 0d |  | 2018-06-21 | Damien; Maarten; Maria; Moustafa; Wouter |  |  |  |  |
| 54 | 1.11 | EPS@ISEP 2018 Closing & Certificate Awarding Session: Hand-in Prototype, CD, printed Report + Poster | milestone | 0d | 2018-02-28 A | 2018-02-28 A |  | 100% | 2018-02-28 | 2018-02-28 | 0d |  | 2018-06-28 | Damien; Maarten; Maria; Moustafa; Wouter |  |  |  |  |
